# Trivergent Alliance Care Transformation Work Plan 12.21.15

Schedule from MS Project, 2016-01-04 to 2019-12-31, A marks actual dates.
Meritus Health, Inc.

## Calendars

- Standard: Mon-Fri 08:00-12:00, 13:00-17:00; Sat-Sun off.

## Resources

| Resource |
| --- |
| Strategy 1 Team Leads |
| MMC Strategy 2 Team Lead |
| WMHS Strategy 2 Team Lead |
| WMHS CM Director |
| Strategy 3 Team Lead |
| FRHS Strategy 3 Team Lead |
| Strategy 2 Team Lead |
| Project Manager |
| Executive Committee |

## Schedule

| ID | WBS | Task | Type | Duration | Start | Finish | Predecessors | Total slack | Free slack | Constraint | Resources | Work |
| --- | --- | --- | --- | --- | --- | --- | --- | --- | --- | --- | --- | --- |
| 1 | 1 | Receipt of Awarded Notification | milestone | 1d | 2016-02-01 | 2016-02-01 |  | 1021d |  |  | Executive Committee | 8h |
| 2 | 2 | Align the Regional Partnership Care Transformation Budget to align with Award Value | milestone | 4d | 2016-02-02 | 2016-02-05 |  | 1017d |  | finish no earlier than 2016-02-05 | Executive Committee | 32h |
| 4 | 3 | **Behavioral Health 1.1 Replicate Case Management** |  | 1041d? | 2016-01-04 | 2019-12-30 |  | 1d |  |  |  | 72304h |
| 5 | 3.1 | Create Regional Behavioral Health Case Mgr job description and scope |  | 8d | 2016-02-01 | 2016-02-10 |  | 1014d |  |  | Strategy 1 Team Leads | 64h |
| 6 | 3.2 | Develop BH CM training content |  | 20d | 2016-02-01 | 2016-02-26 |  | 1002d |  |  | Strategy 1 Team Leads | 160h |
| 7 | 3.3 | Develop standardized documentation |  | 20d | 2016-02-01 | 2016-02-26 |  | 1002d |  |  | Strategy 1 Team Leads | 160h |
| 8 | 3.4 | Develop reporting system for tracking outcomes |  | 40d | 2016-02-01 | 2016-03-25 |  | 982d |  |  | Strategy 1 Team Leads | 320h |
| 9 | 3.5 | Hire / re-deploy Regional BH Case Managers |  | 40d | 2016-02-01 | 2016-03-25 |  | 762d | 0d |  | Strategy 1 Team Leads | 320h |
| 10 | 3.6 | Training and orientation of staff |  | 40d | 2016-03-28 | 2016-05-20 | 9 | 762d | 0d |  | Strategy 1 Team Leads | 320h |
| 11 | 3.7 | Deploy staff to begin seeing all BH patients referred from acute care services |  | 180d | 2016-05-23 | 2017-01-27 | 10 | 762d |  |  | Strategy 1 Team Leads | 1440h |
| 12 | 3.8 | Conduct 30 day review with new hires |  | 20d | 2016-05-02 | 2016-05-27 |  | 937d |  | start no earlier than 2016-05-02 | Strategy 1 Team Leads | 160h |
| 13 | 3.9 | Conduct 90 day review with new hires |  | 20d | 2016-06-01 | 2016-06-28 |  | 915d |  | start no earlier than 2016-06-01 | Strategy 1 Team Leads | 160h |
| 14 | 3.10 | Tracking and documentation using standard form |  | 196d | 2016-04-01 | 2016-12-30 |  | 782d |  | finish no earlier than 2016-12-30 | Strategy 1 Team Leads | 1568h |
| 15 | 3.11 | Evaluate metrics quarterly | milestone | 21d | 2016-07-01 | 2016-07-29 |  | 892d |  | start no earlier than 2016-07-01 | Strategy 1 Team Leads | 168h |
| 16 | 3.12 | Evaluate metrics quarterly | milestone | 21d | 2016-10-03 | 2016-10-31 |  | 826d |  | start no earlier than 2016-10-03 | Strategy 1 Team Leads | 168h |
| 17 | 3.13 | Evaluate metrics quarterly | milestone | 21d | 2017-01-02 | 2017-01-30 |  | 761d |  | start no earlier than 2017-01-02 | Strategy 1 Team Leads | 168h |
| 18 | 3.14 | Evaluate metrics quarterly | milestone | 19d | 2017-04-04 | 2017-04-28 |  | 697d |  | start no earlier than 2017-04-04 | Strategy 1 Team Leads | 152h |
| 19 | 3.15 | Determine patient satisfaction metric |  | 40d | 2016-02-01 | 2016-03-25 |  | 982d |  |  | Strategy 1 Team Leads | 320h |
| 20 | 3.16 | Determine standard method for tracking and reporting physician satisfaction metric |  | 60d | 2016-02-01 | 2016-04-22 |  | 962d |  |  | Strategy 1 Team Leads | 480h |
| 22 | 3.17 | **Behavioral Health 1.2 Integration in Primary Care** |  | 1041d? | 2016-01-04 | 2019-12-30 |  | 1d |  |  | Strategy 1 Team Leads | 66176h |
| 23 | 3.17.1 | Create Regional Masters licensed BH clinician job description and scope |  | 5d | 2016-01-04 | 2016-01-08 |  | 937d | 0d | finish no earlier than 2016-01-08 | Strategy 1 Team Leads | 40h |
| 24 | 3.17.2 | Develop BH CM training content |  | 20d | 2016-02-01 | 2016-02-26 |  | 1002d |  |  | Strategy 1 Team Leads | 160h |
| 25 | 3.17.3 | Develop standardized documentation |  | 20d | 2016-02-01 | 2016-02-26 |  | 1002d |  |  | Strategy 1 Team Leads | 160h |
| 26 | 3.17.4 | Develop reporting system for tracking outcomes |  | 20d | 2016-02-01 | 2016-02-26 |  | 1002d |  |  | Strategy 1 Team Leads | 160h |
| 27 | 3.17.5 | Define and implement method to track PHQ 2 and PHQ 9 results |  | 20d | 2016-02-01 | 2016-02-26 |  | 1002d |  |  | Strategy 1 Team Leads | 160h |
| 28 | 3.17.6 | Work with IT to build reports to break results down into: 1-4, 5-9 (at risk), 9-14 (moderate), 15-19 (moderately sever, 20-27 (severe) |  | 30d | 2016-02-01 | 2016-03-11 |  | 992d |  |  | Strategy 1 Team Leads | 240h |
| 29 | 3.17.7 | Clarify scope of service for BH clinician located in PCP office |  | 20d | 2016-02-01 | 2016-02-26 |  | 1002d |  |  | Strategy 1 Team Leads | 160h |
| 30 | 3.17.8 | Partner with PCP providers and practice managers |  | 20d | 2016-02-01 | 2016-02-26 |  | 1002d |  |  | Strategy 1 Team Leads | 160h |
| 31 | 3.17.9 | Hire / re-deploy Masters licensed BH clinicians for primary care practices |  | 60d | 2016-01-11 | 2016-04-01 | 23 | 937d | 0d | finish no earlier than 2016-03-18 | Strategy 1 Team Leads | 480h |
| 32 | 3.17.10 | Conduct 30 day review with new hires | milestone | 20d | 2016-04-01 | 2016-04-28 |  | 958d |  | start no earlier than 2016-04-01 | Strategy 1 Team Leads | 160h |
| 33 | 3.17.11 | Training and orientation of staff |  | 40d | 2016-04-04 | 2016-05-27 | 31 | 937d |  |  | Strategy 1 Team Leads | 320h |
| 34 | 3.17.12 | Deploy staff to begin seeing BH patients referred by PCP |  | 150d | 2016-05-02 | 2016-11-25 |  | 807d |  | start no earlier than 2016-05-02 | Strategy 1 Team Leads | 1200h |
| 35 | 3.17.13 | Develop provider training for PHQ2/9 |  | 40d | 2016-02-05 | 2016-03-31 |  | 873d | 1d | finish no earlier than 2016-03-31 | Strategy 1 Team Leads | 320h |
| 36 | 3.17.14 | Provide PHQ 2/9 education to PCP team |  | 45d | 2016-04-04 | 2016-06-03 | 35 | 872d | 0d | start no earlier than 2016-04-04 | Strategy 1 Team Leads | 360h |
| 37 | 3.17.15 | Conduct 90 day review with new hires | milestone | 20d | 2016-06-02 | 2016-06-29 |  | 914d |  | start no earlier than 2016-06-02 | Strategy 1 Team Leads | 160h |
| 38 | 3.17.16 | Evaluate PCP office processes and implement use of PHQ 2/9 |  | 60d | 2016-06-06 | 2016-08-26 | 36 | 872d |  |  | Strategy 1 Team Leads | 480h |
| 39 | 3.17.17 | Tracking and documentation using standard form |  | 140d | 2016-06-01 | 2016-12-13 |  | 795d |  | start no earlier than 2016-06-01 | Strategy 1 Team Leads | 1120h |
| 40 | 3.17.18 | BH clinicians begin seeing BH patients referred by PCP using PHQ 9 scoring | milestone | 1d? | 2016-05-02 | 2016-05-02 |  | 956d |  | start no earlier than 2016-05-02 | Strategy 1 Team Leads | 8h |

| ID | WBS | Task | Duration | Start | Finish | Predecessors | Total slack | Free slack | Constraint | Resources | Work |
| --- | --- | --- | --- | --- | --- | --- | --- | --- | --- | --- | --- |
| 42 | 3.17.19 | **BH 1.3: Reduce Stigma and Increase Understanding of Behavioral Health** | 1021d | 2016-02-01 | 2019-12-30 |  | 1d |  |  | Strategy 1 Team Leads | 21392h |
| 43 | 3.17.19.1 | Create Regional Health Education Coordinator job description and scope | 8d | 2016-02-01 | 2016-02-10 |  | 934d | 0d |  | Strategy 1 Team Leads | 64h |
| 44 | 3.17.19.2 | Recruit and hire a regional community health education coordinator | 60d | 2016-02-11 | 2016-05-04 | 43 | 934d | 0d |  | Strategy 1 Team Leads | 480h |
| 45 | 3.17.19.3 | Coordinator obtain MHFA certification | 20d | 2016-05-05 | 2016-06-01 | 44 | 934d |  |  | Strategy 1 Team Leads | 160h |
| 46 | 3.17.19.4 | Inventory existing MHFA and other training to targeted groups | 60d | 2016-02-01 | 2016-04-22 |  | 962d |  |  | Strategy 1 Team Leads | 480h |
| 47 | 3.17.19.5 | With CAC-develop a training plan-including partners, schedule, logistics. | 40d | 2016-03-01 | 2016-04-25 |  | 961d |  | start no earlier than 2016-03-01 | Strategy 1 Team Leads | 320h |
| 48 | 3.17.19.6 | Implement community health education/MHFA throughout region. | 955d | 2016-05-03 | 2019-12-30 |  | 1d |  | start no earlier than 2016-05-03 | Strategy 1 Team Leads | 7640h |
| 49 | 3.17.19.7 | Create needed materials to increase awareness of behavioral health needs, including zone cards. | 90d | 2016-04-04 | 2016-08-05 |  | 887d |  | start no earlier than 2016-04-04 | Strategy 1 Team Leads | 720h |
| 50 | 3.17.19.8 | Distribute consistent education with partners to support appropriate resource utilization. | 120d | 2016-08-01 | 2017-01-13 |  | 772d |  | start no earlier than 2016-08-01 | Strategy 1 Team Leads | 960h |
| 51 | 3.17.19.9 | Gather training data by audience type and ED metric. | 140d | 2016-06-02 | 2016-12-14 |  | 794d |  | start no earlier than 2016-06-02 | Strategy 1 Team Leads | 1120h |
| 52 | 3.17.19.10 | Collaborate with partners to insure availability of certified instructors | 160d | 2016-02-01 | 2016-09-09 |  | 862d |  |  | Strategy 1 Team Leads | 1280h |
| 54 | 3.17.20 | **Strategy 2 CCM: WMHS- Introduction/Expansion of Complex Care Models at WMHS** | 435d? | 2016-02-01 | 2017-09-29 |  | 587d |  |  | WMHS Strategy 2 Team Lead | 12784h |
| 55 | 3.17.20.1 | Hire CHW (9) | 162d | 2016-02-01 | 2017-06-02 |  | 672d |  |  | WMHS Strategy 2 Team Lead | 1296h |
| 56 | 3.17.20.2 | Hire NP (2) | 100d | 2016-02-12 | 2016-06-30 |  | 853d | 0d | finish no earlier than 2016-06-30 | WMHS Strategy 2 Team Lead | 800h |
| 57 | 3.17.20.3 | Hire Medical Assistant/Registrar (1) | 60d | 2016-02-08 | 2016-04-29 |  | 957d |  | finish no earlier than 2016-04-29 | WMHS Strategy 2 Team Lead | 480h |
| 58 | 3.17.20.4 | Hire Community Health Workers (2) | 80d | 2016-06-01 | 2016-09-20 | 137 | 855d |  | finish no earlier than 2016-05-31 | WMHS Strategy 2 Team Lead | 640h |
| 59 | 3.17.20.5 | Hire RN CM (2) | 80d | 2016-02-10 | 2016-05-31 |  | 935d |  | finish no earlier than 2016-05-31 | WMHS Strategy 2 Team Lead | 640h |
| 60 | 3.17.20.6 | Hire Registered Dietician (1) | 80d | 2016-02-01 | 2016-05-20 |  | 942d |  |  | WMHS Strategy 2 Team Lead | 640h |
| 61 | 3.17.20.7 | Hire Pharmacists (1) | 160d | 2017-02-20 | 2017-09-29 |  | 587d |  | finish no earlier than 2017-09-29 | WMHS Strategy 2 Team Lead | 1280h |
| 62 | 3.17.20.8 | Hire Social Work Care Managers (1) | 80d | 2016-02-10 | 2016-05-31 |  | 935d |  | finish no earlier than 2016-05-31 | WMHS Strategy 2 Team Lead | 640h |
| 63 | 3.17.20.9 | Train NP (2) | 60d | 2016-07-01 | 2016-09-22 | 56 | 853d |  | finish no earlier than 2016-08-31 | WMHS Strategy 2 Team Lead | 480h |
| 64 | 3.17.20.10 | Train Medical Assistant/Registrar (1) | 60d | 2016-05-09 | 2016-07-29 |  | 892d |  | finish no earlier than 2016-07-29 | WMHS Strategy 2 Team Lead | 480h |
| 65 | 3.17.20.11 | Train Community Health Workers (2) | 60d | 2016-05-09 | 2016-07-29 |  | 892d |  | finish no earlier than 2016-07-29 | WMHS Strategy 2 Team Lead | 480h |
| 66 | 3.17.20.12 | Train RN CM (2) | 60d | 2016-05-09 | 2016-07-29 |  | 892d |  | finish no earlier than 2016-07-29 | WMHS Strategy 2 Team Lead | 480h |
| 67 | 3.17.20.13 | Train Registered Dietician (1) | 60d | 2016-05-09 | 2016-07-29 |  | 892d |  | finish no earlier than 2016-07-29 | WMHS Strategy 2 Team Lead | 480h |
| 68 | 3.17.20.14 | Train Pharmacist (1) | 60d | 2016-09-08 | 2016-11-30 |  | 804d |  | finish no earlier than 2016-11-30 | WMHS Strategy 2 Team Lead | 480h |
| 69 | 3.17.20.15 | Train Social Work Care Managers (1) | 1d? | 2016-07-29 | 2016-07-29 |  | 892d |  | finish no earlier than 2016-07-29 | WMHS Strategy 2 Team Lead | 8h |

| ID | WBS | Task | Duration | Start | Finish | Predecessors | Total slack | Free slack | Constraint | Resources | Work |
| --- | --- | --- | --- | --- | --- | --- | --- | --- | --- | --- | --- |
| 71 | 3.17.21 | **Strategy 2 CCM- MMC Complex Care Models at MMC** | 230d? | 2016-02-08 | 2016-12-23 |  | 787d |  |  | MMC Strategy 2 Team Lead | 8640h |
| 72 | 3.17.21.1 | Hire Community Health Workers (9) | 80d | 2016-02-10 | 2016-05-31 |  | 935d |  | finish no earlier than 2016-05-31 | MMC Strategy 2 Team Lead | 640h |
| 73 | 3.17.21.2 | Hire RN Care Manager (1) | 80d | 2016-02-10 | 2016-05-31 |  | 935d |  | finish no earlier than 2016-05-31 | MMC Strategy 2 Team Lead | 640h |
| 74 | 3.17.21.3 | Hire Respiratory Therapist (1) | 60d? | 2016-02-08 | 2016-04-29 |  | 957d |  | finish no earlier than 2016-04-29 | MMC Strategy 2 Team Lead | 480h |
| 75 | 3.17.21.4 | Hire Registered Dietician (2) | 60d? | 2016-02-08 | 2016-04-29 |  | 957d |  | finish no earlier than 2016-04-29 | MMC Strategy 2 Team Lead | 480h |
| 76 | 3.17.21.5 | Hire Social Work Care Manager (3) | 80d | 2016-02-10 | 2016-05-31 |  | 935d |  | finish no earlier than 2016-05-31 | MMC Strategy 2 Team Lead | 640h |
| 77 | 3.17.21.6 | Hire Pharmacists (2.2) | 120d | 2016-04-18 | 2016-09-30 |  | 787d | 0d | finish no earlier than 2016-09-30 | MMC Strategy 2 Team Lead | 960h |
| 78 | 3.17.21.7 | Develop Registered Dietician service line and scope of work | 10d | 2016-02-08 | 2016-02-19 |  | 1007d |  | finish no earlier than 2016-02-19 | MMC Strategy 2 Team Lead | 80h |
| 79 | 3.17.21.8 | Train CHW staff (9) | 60d | 2016-06-09 | 2016-08-31 | 137 | 869d |  | finish no earlier than 2016-08-31 | MMC Strategy 2 Team Lead | 480h |
| 80 | 3.17.21.9 | Train RN Care Manager (1) | 60d | 2016-06-09 | 2016-08-31 |  | 869d |  | finish no earlier than 2016-08-31 | MMC Strategy 2 Team Lead | 480h |
| 81 | 3.17.21.10 | Train Respiratory Therapist (1) | 60d | 2016-05-09 | 2016-07-29 |  | 892d |  | finish no earlier than 2016-07-29 | MMC Strategy 2 Team Lead | 480h |
| 82 | 3.17.21.11 | Train Registered Dietician (2) | 60d | 2016-05-09 | 2016-07-29 |  | 892d |  | finish no earlier than 2016-07-29 | MMC Strategy 2 Team Lead | 480h |
| 83 | 3.17.21.12 | Train Social Work Care Manager (3) | 60d | 2016-05-09 | 2016-07-29 |  | 892d |  | finish no earlier than 2016-07-29 | MMC Strategy 2 Team Lead | 480h |
| 84 | 3.17.21.13 | Train Pharmacists (2.2) | 60d | 2016-10-03 | 2016-12-23 | 77 | 787d |  | finish no earlier than 2016-11-30 | MMC Strategy 2 Team Lead | 480h |
| 86 | 3.17.22 | **Strategy 2 CCM- FRHS: Complex Care Models at FRHS** | 148d? | 2016-02-08 | 2016-08-31 |  | 869d |  |  | FRHS Strategy 3 Team Lead | 9184h |
| 87 | 3.17.22.1 | Hire RN CM (2) | 80d | 2016-02-10 | 2016-05-31 |  | 935d |  | finish no earlier than 2016-05-31 | FRHS Strategy 3 Team Lead | 640h |
| 88 | 3.17.22.2 | Hire Community Health Workers (9) | 80d | 2016-02-10 | 2016-05-31 |  | 935d |  | finish no earlier than 2016-05-31 | FRHS Strategy 3 Team Lead | 640h |
| 89 | 3.17.22.3 | Hire RN Clinical Manager (1) | 80d | 2016-02-10 | 2016-05-31 |  | 935d |  | finish no earlier than 2016-05-31 | FRHS Strategy 3 Team Lead | 640h |
| 90 | 3.17.22.4 | Hire NP (1.5) | 100d | 2016-02-12 | 2016-06-30 |  | 913d |  | finish no earlier than 2016-06-30 | FRHS Strategy 3 Team Lead | 800h |
| 91 | 3.17.22.5 | Hire Receptionist (1) | 60d | 2016-02-08 | 2016-04-29 |  | 957d |  | finish no earlier than 2016-04-29 | FRHS Strategy 3 Team Lead | 480h |
| 92 | 3.17.22.6 | Hire Respiratory Therapist (1) | 60d | 2016-02-08 | 2016-04-29 |  | 957d |  | finish no earlier than 2016-04-29 | FRHS Strategy 3 Team Lead | 480h |
| 93 | 3.17.22.7 | Hire Registered Dietician (1) | 60d | 2016-02-08 | 2016-04-29 |  | 957d |  | finish no earlier than 2016-04-29 | FRHS Strategy 3 Team Lead | 480h |
| 94 | 3.17.22.8 | Hire Social Work Care Manager (1) | 80d | 2016-02-10 | 2016-05-31 |  | 935d |  | finish no earlier than 2016-05-31 | FRHS Strategy 3 Team Lead | 640h |
| 95 | 3.17.22.9 | Train CHW staff (9) | 60d | 2016-06-01 | 2016-08-23 | 137 | 875d |  | finish no earlier than 2016-07-29 | FRHS Strategy 3 Team Lead | 480h |
| 96 | 3.17.22.10 | Train RN CM(2) | 60d | 2016-05-09 | 2016-07-29 |  | 892d |  | finish no earlier than 2016-07-29 | FRHS Strategy 3 Team Lead | 480h |
| 97 | 3.17.22.11 | Train RN Clinical Manager for Clinic (1) | 60d | 2016-05-09 | 2016-07-29 |  | 892d |  | finish no earlier than 2016-07-29 | FRHS Strategy 3 Team Lead | 480h |
| 98 | 3.17.22.12 | Train NP(1.5) | 60d? | 2016-06-09 | 2016-08-31 |  | 869d |  | finish no earlier than 2016-08-31 | FRHS Strategy 3 Team Lead | 480h |
| 99 | 3.17.22.13 | Train Receptionist (1) | 40d | 2016-04-06 | 2016-05-31 |  | 935d |  | finish no earlier than 2016-05-31 | FRHS Strategy 3 Team Lead | 320h |
| 100 | 3.17.22.14 | Train Respiratory Therapist (1) | 40d | 2016-04-06 | 2016-05-31 |  | 935d |  | finish no earlier than 2016-05-31 | FRHS Strategy 3 Team Lead | 320h |
| 101 | 3.17.22.15 | Train Registered Dietician (1) | 40d | 2016-04-06 | 2016-05-31 |  | 935d |  | finish no earlier than 2016-05-31 | FRHS Strategy 3 Team Lead | 320h |
| 102 | 3.17.22.16 | Train Social Work Care Manager (1) | 40d | 2016-04-06 | 2016-05-31 |  | 935d |  | finish no earlier than 2016-05-31 | FRHS Strategy 3 Team Lead | 320h |

| ID | WBS | Task | Type | Duration | Start | Finish | Predecessors | Total slack | Free slack | Constraint | Resources | Work |
| --- | --- | --- | --- | --- | --- | --- | --- | --- | --- | --- | --- | --- |
| 104 | 4 | **Strategy 3: Decrease ED Avoidable Use** |  | 239d? | 2016-02-15 | 2017-01-12 |  | 19d |  |  | Strategy 3 Team Lead | 12736h |
| 105 | 4.1 | **CHW Deployment for ED HU** |  | 101d? | 2016-03-09 | 2016-07-27 |  | 894d |  |  | Strategy 3 Team Lead | 1616h |
| 106 | 4.1.1 | Hire CHW's (9.6) |  | 60d | 2016-03-09 | 2016-05-31 |  | 935d |  | finish no earlier than 2016-05-31 | Strategy 3 Team Lead | 480h |
| 107 | 4.1.2 | Train CHW's (9.6) |  | 40d | 2016-06-01 | 2016-07-26 | 137 | 894d | 0d | finish no earlier than 2016-06-30 | Strategy 3 Team Lead | 320h |
| 108 | 4.1.3 | Deploy Resources |  | 1d? | 2016-07-27 | 2016-07-27 | 107 | 894d |  | finish no earlier than 2016-06-30 | Strategy 3 Team Lead | 8h |
| 109 | 4.2 | **Paramedicine** |  | 239d? | 2016-02-15 | 2017-01-12 |  | 773d |  |  | Strategy 3 Team Lead | 6736h |
| 110 | 4.2.1 | Partner with Community EMS re. development of paramedicine program |  | 120d | 2016-02-15 | 2016-07-29 |  | 892d |  | finish no earlier than 2016-07-29 | Strategy 3 Team Lead | 960h |
| 111 | 4.2.2 | MEIMMS approval to implement Paramedicine Program | milestone | 1d? | 2016-07-15 | 2016-07-15 |  | 902d |  | finish no earlier than 2016-07-15 | Strategy 3 Team Lead | 8h |
| 112 | 4.2.3 | Determination if Program will benefit ED HU Pop. |  | 1d? | 2016-07-29 | 2016-07-29 |  | 891d | 0d | finish no earlier than 2016-07-29 | Strategy 3 Team Lead | 8h |
| 113 | 4.2.4 | Proceed with Partnering with State of MD | milestone | 1d? | 2016-08-01 | 2016-08-01 | 112 | 891d |  |  | Strategy 3 Team Lead | 8h |
| 114 | 4.2.5 | Recruit staff (3; 1/Sponsor Hospital) |  | 90d | 2016-02-26 | 2016-06-30 |  | 913d |  | finish no earlier than 2016-06-30 | Strategy 3 Team Lead | 720h |
| 115 | 4.2.6 | Train and orient (3; 1/Sponsor Hospital) |  | 60d | 2016-06-09 | 2016-08-31 |  | 869d |  | finish no earlier than 2016-08-31 | Strategy 3 Team Lead | 480h |
| 116 | 4.2.7 | Develop Tracking and Documentation |  | 60d | 2016-06-09 | 2016-08-31 |  | 869d |  | finish no earlier than 2016-08-31 | Strategy 3 Team Lead | 480h |
| 117 | 4.2.8 | Evaluate Metrics Quarterly |  | 90d | 2016-05-30 | 2016-09-30 |  | 847d |  | finish no earlier than 2016-09-30 | Strategy 3 Team Lead | 720h |
| 118 | 4.2.9 | Define Process Metrics |  | 60d | 2016-05-09 | 2016-07-29 |  | 892d |  | finish no earlier than 2016-07-29 | Strategy 3 Team Lead | 480h |
| 119 | 4.2.10 | Define Program requirements, resources, develop implementation plan |  | 120d | 2016-07-29 | 2017-01-12 |  | 773d |  | start no earlier than 2016-07-29 | Strategy 3 Team Lead | 960h |
| 120 | 4.3 | **Telemedicine** |  | 148d? | 2016-03-07 | 2016-09-28 |  | 4d |  |  | Strategy 3 Team Lead | 2472h |
| 121 | 4.3.1 | Select and contract w/vendor of choice; include IT and purchasing at the table |  | 40d | 2016-03-07 | 2016-04-29 |  | 956d | 23d | finish no earlier than 2016-04-29 | Strategy 3 Team Lead | 320h |
| 122 | 4.3.2 | Define new workflows needed for CM Nurses |  | 30d | 2016-03-21 | 2016-04-29 |  | -6d | 0d | finish no earlier than 2016-04-29 | Strategy 3 Team Lead | 240h |
| 123 | 4.3.3 | Training and education of staff |  | 20d | 2016-05-05 | 2016-06-01 |  | 933d | 0d | finish no earlier than 2016-06-01 | Strategy 3 Team Lead | 160h |
| 124 | 4.3.4 | Deployment of patient monitoring system | milestone | 1d? | 2016-06-02 | 2016-06-02 | 123, 121 | 933d |  |  | Strategy 3 Team Lead | 8h |
| 125 | 4.3.5 | Tracking and documentation using standard form |  | 20d | 2016-05-02 | 2016-05-27 | 122 | 937d |  |  | Strategy 3 Team Lead | 160h |
| 126 | 4.3.6 | Evaluate metrics quarterly |  | 20d | 2016-09-01 | 2016-09-28 |  | 849d |  | start no earlier than 2016-09-01 | Strategy 3 Team Lead | 160h |
| 127 | 4.3.7 | Define process metrics based on new workflow |  | 30d | 2016-04-22 | 2016-06-02 | 122 | -6d | 0d | finish no later than 2016-06-02 | Strategy 3 Team Lead | 240h |

Notes:
- 105: WMHS- CHW / FRHS- CHW / MMC-CHW
- 106: FRHS- 3.2 FTE / WMHS- 3.2 FTE / MMC- 3.2 FTE
- 107: FRHS- 3.2 FTE / WMHS- 3.2 FTE / MMC- 3.2 FTE
- 119: If State's Paramedicine Program does not align with ED HU, will define geographic hot spot program that targets ED HU and the EMs areas that is driving the highest call volume. 4 months to define out work flow details to design pilot, then 2 months to implement. Will require EMS data to determine hot spots.

| ID | WBS | Task | Type | Duration | Start | Finish | Predecessors | Complete | Remaining | Total slack | Free slack | Constraint | Resources | Work | Actual work |
| --- | --- | --- | --- | --- | --- | --- | --- | --- | --- | --- | --- | --- | --- | --- | --- |
| 129 | 5 | **Strategy 4: (RCMEC) Regional Care Management Education Center** |  | 1022d? | 2016-02-01 A | 2019-12-31 |  |  | 1017.75d? | 0d |  |  | Strategy 2 Team Lead | 29544h | 114h |
| 130 | 5.1 | Create CM education Specialist Job duties and scope |  | 10d? | 2016-02-01 | 2016-02-12 |  |  |  | 1012d |  | finish no earlier than 2016-02-12 | Strategy 2 Team Lead | 80h |  |
| 131 | 5.2 | Create regional coordinator job duties and scope |  | 10d? | 2016-02-01 | 2016-02-12 |  |  |  | 1012d |  | finish no earlier than 2016-02-12 | Strategy 2 Team Lead | 80h |  |
| 132 | 5.3 | Create Regional Education Community Partner Liaison Job duties and Scope |  | 10d? | 2016-02-01 | 2016-02-12 |  |  |  | 1012d |  | finish no earlier than 2016-02-12 | Strategy 2 Team Lead | 80h |  |
| 133 | 5.4 | Hire CM Education Specialist |  | 60d | 2016-02-08 | 2016-04-29 |  |  |  | 957d |  | finish no earlier than 2016-04-29 | Strategy 2 Team Lead | 480h |  |
| 134 | 5.5 | Hire Regional Coordinator |  | 60d | 2016-02-08 | 2016-04-29 |  |  |  | 957d |  | finish no earlier than 2016-04-29 | Strategy 2 Team Lead | 480h |  |
| 135 | 5.6 | Hire Regional Education Community Partner Liaison |  | 60d | 2016-02-08 | 2016-04-29 |  |  |  | 957d |  | finish no earlier than 2016-04-29 | Strategy 2 Team Lead | 480h |  |
| 136 | 5.7 | Train CM Education Specialist |  | 60d | 2016-03-09 | 2016-05-31 |  |  |  | 935d |  | finish no earlier than 2016-05-31 | Strategy 2 Team Lead | 480h |  |
| 137 | 5.8 | Develop CHW Training Content |  | 60d | 2016-03-09 | 2016-05-31 |  |  |  | 855d | 0d | finish no earlier than 2016-05-31 | Strategy 2 Team Lead | 480h |  |
| 138 | 5.9 | Create Training Schedule for CHW |  | 60d | 2016-03-09 | 2016-05-31 |  |  |  | 935d |  | finish no earlier than 2016-05-31 | Strategy 2 Team Lead | 480h |  |
| 139 | 5.10 | Develop Annual CM survey for educational gaps |  | 10d | 2016-02-01 | 2016-02-12 |  |  |  | 78d | 0d |  | Strategy 2 Team Lead | 80h |  |
| 140 | 5.11 | Administer the internal annual CM survey for education gaps to sponsor hospitals CMs |  | 10d | 2016-02-15 A | 2016-02-26 A | 139 | 100% |  |  |  |  | Strategy 2 Team Lead | 80h | 80h |
| 141 | 5.12 | Survey Community Care Mgmt partners to ID educational needs |  | 30d | 2016-06-02 | 2016-07-13 | 139 |  |  | 0d |  | start no earlier than 2016-06-02 | Strategy 2 Team Lead | 240h |  |
| 142 | 5.13 | **Infrastructure Build Out** |  | 266d? | 2016-02-01 | 2017-02-06 |  |  |  | 756d |  |  | Strategy 2 Team Lead | 6136h |  |
| 143 | 5.13.1 | Procure and Implement CM Training System |  | 20d | 2016-02-01 | 2016-02-26 |  |  |  | 942d | 0d |  | Strategy 2 Team Lead | 160h |  |
| 144 | 5.13.2 | Implement Training for current staff |  | 60d | 2016-02-29 | 2016-05-20 | 143 |  |  | 942d |  |  | Strategy 2 Team Lead | 480h |  |
| 145 | 5.13.3 | Implement training for new staff |  | 180d | 2016-05-31 | 2017-02-06 |  |  |  | 756d |  | start no earlier than 2016-05-31 | Strategy 2 Team Lead | 1440h |  |
| 146 | 5.13.4 | Develop Centralized Internet Registration Program |  | 60d | 2016-06-01 | 2016-08-23 |  |  |  | 874d | 0d | start no earlier than 2016-06-01 | Strategy 2 Team Lead | 480h |  |
| 147 | 5.13.5 | Deploy Centralized Internet Registration Program | milestone | 1d? | 2016-08-24 | 2016-08-24 | 146 |  |  | 874d |  |  | Strategy 2 Team Lead | 8h |  |
| 148 | 5.13.6 | Secure Contract for Web/Tele- Conferencing Capabilities |  | 40d | 2016-02-01 | 2016-03-25 |  |  |  | 962d | 0d |  | Strategy 2 Team Lead | 320h |  |
| 149 | 5.13.7 | Procure Needed Infrastructure for Web/Tele-Conferencing Capabilities |  | 20d | 2016-03-28 | 2016-04-22 | 148 |  |  | 962d |  |  | Strategy 2 Team Lead | 160h |  |
| 150 | 5.13.8 | Procure Laptops and Docking Stations (100) |  | 15d | 2016-02-01 | 2016-02-19 |  |  |  | 1007d |  |  | Strategy 2 Team Lead | 120h |  |
| 151 | 5.13.9 | Configuration Laptops and Docking Stations per Health System (100) |  | 45d | 2016-02-01 | 2016-04-01 |  |  |  | 977d |  |  | Strategy 2 Team Lead | 360h |  |
| 152 | 5.13.10 | Procure Cell Phones with Data Tethering (50) |  | 15d | 2016-02-01 | 2016-02-19 |  |  |  | 1007d |  |  | Strategy 2 Team Lead | 120h |  |
| 153 | 5.13.11 | Configure Cell Phones with Data Tethering (50) |  | 45d | 2016-02-01 | 2016-04-01 |  |  |  | 977d |  |  | Strategy 2 Team Lead | 360h |  |
| 154 | 5.14 | Build Health Coach Training |  | 60d | 2016-02-01 | 2016-04-22 |  |  |  | 802d | 0d | start no earlier than 2016-02-01 | Strategy 2 Team Lead | 480h |  |
| 155 | 5.15 | Implement Health Coach Training |  | 160d | 2016-04-25 | 2016-12-02 | 154 |  |  | 802d |  | start no earlier than 2016-02-01 | Strategy 2 Team Lead | 1280h |  |
| 156 | 5.16 | Procurement of Disease Management Curriculum |  | 60d | 2016-03-01 | 2016-05-23 |  |  |  | 901d | 0d | start no earlier than 2016-03-01 | Strategy 2 Team Lead | 480h |  |
| 157 | 5.17 | Implementation of Disease Mgmt Curriculum (Engages IT) |  | 40d | 2016-05-24 | 2016-07-18 | 156 |  |  | 901d |  | start no earlier than 2016-02-01 | Strategy 2 Team Lead | 320h |  |
| 158 | 5.18 | Training on Disease Mgmt Curriculum |  | 20d | 2016-05-16 | 2016-06-10 |  |  |  | 707d | 0d | start no earlier than 2016-05-16 | Strategy 2 Team Lead | 160h |  |
| 159 | 5.19 | Develop and Curriculum for New Hires and Continuing Ed Tracks |  | 40d | 2016-06-13 | 2016-08-05 | 158 |  |  | 707d | 0d | start no earlier than 2016-02-01 | Strategy 2 Team Lead | 320h |  |
| 160 | 5.20 | Implement Curriculum Tracks for New Hires and Continuing Education |  | 180d | 2016-08-08 | 2017-04-14 | 159 |  |  | 707d |  | start no earlier than 2016-02-01 | Strategy 2 Team Lead | 1440h |  |
| 161 | 5.21 | Develop Training Curriculum for Community CM Partners |  | 80d | 2016-07-14 | 2016-11-02 | 141 |  |  | 0d |  | start no earlier than 2016-02-01 | Strategy 2 Team Lead | 640h |  |
| 162 | 5.22 | Develop Schedule for CM Partner Training Offerings |  | 90d | 2016-11-03 | 2017-03-08 | 161 |  |  | 0d |  |  | Strategy 2 Team Lead | 720h |  |
| 163 | 5.23 | Begin to offer Community Partner CM Education/Training Sessions/Courses |  | 131d? | 2017-03-09 | 2017-09-07 | 162 |  |  | 0d |  | finish no earlier than 2016-11-30 | Strategy 2 Team Lead | 1048h |  |
| 164 | 5.24 | Develop more robust Curriculum CM Partner Education/Training Session Offerings based on their Needs |  | 90d? | 2017-09-08 | 2018-01-11 | 163 |  |  | 0d |  | start no earlier than 2016-12-30 | Strategy 2 Team Lead | 720h |  |
| 165 | 5.25 | Implement More Robust CM Partner Educational/Training Curriculum (year 3 & 4) |  | 513d? | 2018-01-12 | 2019-12-31 | 164 |  |  | 0d |  | finish no earlier than 2019-12-31 | Strategy 2 Team Lead | 4104h |  |

Notes:
- 142: Components will be defined based on award level and infrastructure approved with final budget.

| ID | WBS | Task | Duration | Start | Finish | Predecessors | Total slack | Free slack | Constraint | Resources | Work |
| --- | --- | --- | --- | --- | --- | --- | --- | --- | --- | --- | --- |
| 167 | 6 | **Enabling Infrastructure (Project Manager in place from planning grant process)** | 1022d? | 2016-02-01 | 2019-12-31 |  | 0d |  |  | Project Manager | 51336h |
| 168 | 6.1 | **On boarding of Additional Workforce to Support Regional Care Transf. Project** | 135d | 2016-02-01 | 2016-08-05 |  | 887d |  |  |  | 5600h |
| 169 | 6.1.1 | **Develop scope of work and job descriptions** | 15d | 2016-02-01 | 2016-02-19 |  | 887d |  |  | Project Manager | 440h |
| 170 | 6.1.1.1 | Project Coordinator | 5d | 2016-02-01 | 2016-02-05 |  | 917d | 0d |  | Project Manager | 40h |
| 171 | 6.1.1.2 | Staff Accountant | 5d | 2016-02-01 | 2016-02-05 |  | 917d | 0d |  | Project Manager | 40h |
| 172 | 6.1.1.3 | Decision Support Analyst | 15d | 2016-02-01 | 2016-02-19 |  | 887d | 0d |  | Project Manager | 120h |
| 173 | 6.1.1.4 | Clinical Managers (1 for each of the 3 sponsor hospitals) | 15d | 2016-02-01 | 2016-02-19 |  | 947d | 0d |  | Project Manager | 120h |
| 174 | 6.1.2 | **Recruited and Hire** | 70d | 2016-02-08 | 2016-05-13 |  | 897d |  |  | Project Manager | 2480h |
| 175 | 6.1.2.1 | Project Coordinator | 60d | 2016-02-08 | 2016-04-29 | 170 | 917d | 0d |  | Project Manager | 480h |
| 176 | 6.1.2.2 | Staff Accountant | 60d | 2016-02-08 | 2016-04-29 | 171 | 917d | 0d |  | Project Manager | 480h |
| 177 | 6.1.2.3 | Decision Support Analyst | 60d | 2016-02-22 | 2016-05-13 | 172 | 887d | 0d |  | Project Manager | 480h |
| 178 | 6.1.2.4 | Clinical Managers (1 for each of the 3 sponsor hospitals) | 60d | 2016-02-22 | 2016-05-13 | 173 | 947d |  |  | Project Manager | 480h |
| 179 | 6.1.3 | **Orient and Train** | 135d | 2016-02-01 | 2016-08-05 |  | 887d |  |  | Project Manager | 2680h |
| 180 | 6.1.3.1 | Project Coordinator | 40d | 2016-05-02 | 2016-06-24 | 175 | 917d |  |  | Project Manager | 320h |
| 181 | 6.1.3.2 | Staff Accountant | 40d | 2016-05-02 | 2016-06-24 | 176 | 917d |  |  | Project Manager | 320h |
| 182 | 6.1.3.3 | Decision Support Analyst | 60d | 2016-05-16 | 2016-08-05 | 177 | 887d |  |  | Project Manager | 480h |
| 183 | 6.1.3.4 | Clinical Managers (1 for each of the 3 sponsor hospitals) | 60d | 2016-02-01 | 2016-04-22 |  | 962d |  |  | Project Manager | 480h |
| 185 | 6.2 | **Performance Measures** | 1022d? | 2016-02-01 | 2019-12-31 |  | 0d |  |  | Project Manager | 26968h |
| 186 | 6.2.1 | **Create performance dashboards for each strategy** | 60d | 2016-02-01 | 2016-04-22 |  | 962d |  |  | Project Manager | 1920h |
| 187 | 6.2.1.1 | Define Standardized Units Of Measurement for each Metric | 60d | 2016-02-01 | 2016-04-22 |  | 962d |  |  | Project Manager | 480h |
| 188 | 6.2.1.2 | Define Goal/Metric | 60d | 2016-02-01 | 2016-04-22 |  | 962d |  |  | Project Manager | 480h |
| 189 | 6.2.1.3 | Refine patient satisfaction metrics | 60d | 2016-02-01 | 2016-04-22 |  | 962d |  |  | Project Manager | 480h |
| 190 | 6.2.2 | Determine standard method for tracking and reporting patient satisfaction metric at each hospital | 120d | 2016-02-01 | 2016-07-15 |  | 902d |  |  | Project Manager | 960h |
| 191 | 6.2.3 | Define and standardize metric reporting processes at the following levels: departmental, hospital and regional levels as per needed time frames as specified by each needed metric | 120d | 2016-02-01 | 2016-07-15 |  | 902d |  |  | Project Manager | 960h |
| 192 | 6.2.4 | Track and Report of Metrics Monthly to Executive Committee | 935d? | 2016-06-01 | 2019-12-31 |  | 0d |  | finish no earlier than 2019-12-31 | Project Manager | 7480h |
| 193 | 6.2.5 | Tracking and Reporting of Metrics to Alliance Board- Quarterly | 934d? | 2016-06-02 | 2019-12-31 |  | 0d |  | finish no earlier than 2019-12-31 | Executive Committee | 7472h |

| ID | WBS | Task | Type | Duration | Start | Finish | Predecessors | Total slack | Free slack | Constraint | Resources | Work |
| --- | --- | --- | --- | --- | --- | --- | --- | --- | --- | --- | --- | --- |
| 195 | 6.3 | **Flagging of HU** |  | 121d? | 2016-02-01 | 2016-07-18 |  | 901d |  |  | Project Manager | 7712h |
| 196 | 6.3.1 | **Develop and deploy flagging mechanism for each strategies HU target populations that can be rapidly deployed** |  | 121d? | 2016-02-01 | 2016-07-18 |  | 901d |  |  | Project Manager | 6744h |
| 197 | 6.3.1.1 | **Per Sponsor Hospital** |  | 60d | 2016-02-01 | 2016-04-22 |  | 962d |  |  | Project Manager | 1920h |
| 198 | 6.3.1.1.1 | WMHS |  | 60d | 2016-02-01 | 2016-04-22 |  | 962d |  |  | Project Manager | 480h |
| 199 | 6.3.1.1.2 | FRHS |  | 60d | 2016-02-01 | 2016-04-22 |  | 962d |  |  | Project Manager | 480h |
| 200 | 6.3.1.1.3 | MMC |  | 60d | 2016-02-01 | 2016-04-22 |  | 962d |  |  | Project Manager | 480h |
| 201 | 6.3.1.2 | **Per Employed Practices** |  | 60d | 2016-02-01 | 2016-04-22 |  | 901d | 0d |  | Project Manager | 1920h |
| 202 | 6.3.1.2.1 | WMHS |  | 60d | 2016-02-01 | 2016-04-22 |  | 901d |  |  | Project Manager | 480h |
| 203 | 6.3.1.2.2 | FRHS |  | 60d | 2016-02-01 | 2016-04-22 |  | 901d |  |  | Project Manager | 480h |
| 204 | 6.3.1.2.3 | MMC |  | 60d | 2016-02-01 | 2016-04-22 |  | 901d |  |  | Project Manager | 480h |
| 205 | 6.3.1.3 | **Define ability within Integrated Community Based Physician Network/ACO** |  | 61d? | 2016-04-25 | 2016-07-18 | 201 | 901d |  |  | Project Manager | 1936h |
| 206 | 6.3.1.3.1 | WMHS |  | 60d | 2016-04-25 | 2016-07-15 |  | 901d | 0d |  | Project Manager | 480h |
| 207 | 6.3.1.3.2 | FRHS-FIHN |  | 60d | 2016-04-25 | 2016-07-15 |  | 901d | 0d |  | Project Manager | 480h |
| 208 | 6.3.1.3.3 | MMC |  | 60d | 2016-04-25 | 2016-07-15 |  | 901d | 0d |  | Project Manager | 480h |
| 209 | 6.3.1.3.4 | Define project plan for implementing HU flagging process in non affiliated ACO practices if possible | milestone | 1d? | 2016-07-18 | 2016-07-18 | 206, 207, 208 | 901d |  | start no earlier than 2016-04-25 | Project Manager | 8h |
| 210 | 6.4 | Develop Electronic Health Record capabilities to allow for more timely recognition of HU's that meet, and no longer meet, inclusion criteria. |  | 180d | 2016-02-01 | 2016-10-07 |  | 842d |  |  | Project Manager | 1440h |
| 211 | 6.5 | Define areas where strategies are targeted to decrease utilization so that sponsor hospitals can adjust in prep. for annual budget process |  | 60d | 2016-02-01 | 2016-04-22 |  | 962d |  |  | Project Manager | 480h |
| 212 | 6.6 | Investigate capability of integrating Care Transformation goals as push goals for evaluations |  | 120d | 2016-02-01 | 2016-07-15 |  | 902d |  |  | Project Manager | 960h |
| 213 | 7 | Community Advisor Council Engagement per Charter (Initiated Nov. 2015) |  | 1022d? | 2016-02-01 | 2019-12-31 |  | 0d |  | start no earlier than 2016-02-01 | Executive Committee | 8176h |
| 214 | 8 | **Physician Engagement** |  | 1022d? | 2016-02-01 | 2019-12-31 |  | 0d |  |  | Executive Committee | 31480h |
| 215 | 8.1 | Employed PCP's of the Sponsor Hospitals |  | 1022d? | 2016-02-01 | 2019-12-31 |  | 0d |  |  | Executive Committee | 8176h |
| 216 | 8.2 | ACO Affiliated PCP's to the Sponsor Hospitals |  | 1022d? | 2016-02-01 | 2019-12-31 |  | 0d |  |  | Executive Committee | 8176h |
| 217 | 8.3 | Investigate to determine ways to engage the non-sponsor hospital affiliated PCP's within compliance of Stark Law |  | 869d? | 2016-09-01 | 2019-12-31 |  | 0d |  | finish no earlier than 2019-12-31 | Executive Committee | 6952h |
